# Paquete 9 de la Cuenca Chicama: (Descolmatación y Encauzamiento Tramo 4 - 0+000-15+800 ) r0

Schedule from Primavera P6, 2024-12-02 to 2026-05-23, data date 2024-12-02.

## Calendars

- CWE 6 días L-S: Mon-Sat 08:00-18:00; Sun off.

## Schedule

| ID | WBS | Activity | Type | Duration | Start | Finish | Predecessors | Total float | Free float | Metrado | Paquetes | Unidad | Filtro |
| --- | --- | --- | --- | --- | --- | --- | --- | --- | --- | --- | --- | --- | --- |
| A5620 |  | Inicio | milestone | 0d | 2024-12-02 | 2024-12-02 |  | 0d |  |  |  |  |  |
| A5630 |  | Fin | milestone | 0d | 2026-05-23 | 2026-05-23 | 400195.1.11, 400195.1.03, 400195.1.05.11, 400195.1.08.01, 400195.1.09, 400195.1.12.03, 400195.1.13, 12.01.01, 400195.8.03.09, 400195.7.01.07, 400195.1.08.02, 400195.2.01.06 | 0d |  |  |  |  |  |
|  | 6 | **PAQUETE 9 DE LA CUENCA CHICAMA: “DESCOLMATACIÓN Y ENCAUZAMIENTO TRAMO 4 - 00+000 - 15+800”** |  |  | 2024-12-02 | 2026-05-23 |  |  |  |  |  |  |  |
|  | 1 | **OBRAS PRELIMINARES** |  |  | 2024-12-02 | 2026-05-23 |  |  |  |  |  |  |  |
|  | 1 | **TRAZO Y REPLANTEO** |  |  | 2024-12-02 | 2026-05-09 |  |  |  |  |  |  |  |
| 400195.1.01 |  | Trazo y replanteo topográfico al inicio de obra |  | 13d | 2024-12-02 | 2024-12-16 | 400195.1.10 SS | 0d |  | 11 | SI | mes |  |
| 400195.1.04 |  | Cartel de Obra de 7.00 x 3.50 m |  | 2d | 2024-12-02 | 2024-12-03 | 400195.1.10 SS | 23d | 11d |  |  |  |  |
| 400195.1.02 |  | Trazo y replanteo topográfico durante la ejecución de obra |  | 424d | 2024-12-17 | 2026-04-24 | 400195.1.04, 400195.1.01 | 12d | 0d |  | SI |  |  |
| 400195.1.03 |  | Levantamiento topografico final de obra |  | 13d | 2026-04-25 | 2026-05-09 | 400195.1.02, 400195.10.02 | 12d |  |  | SI |  |  |
|  | 2 | **CONSTRUCCIÓN DE ACCESO NUEVO** |  |  | 2024-12-05 | 2025-01-11 |  |  |  |  |  |  |  |
| 400195.1.05.08 |  | Desbroce y remoción de suelo vegetal con equipo |  | 12d | 2024-12-05 | 2024-12-18 | 400195.1.01 SS+3d | 0d |  | 9300 | SI | m3 |  |
| 400195.1.05.09 |  | Transporte de material excedente a DMO, d<=1km |  | 11d | 2024-12-06 | 2024-12-18 | 400195.1.05.08 SS+1d | 335d | 0d | 9300 | SI | m3 | Transporte |
| 400195.1.05.10 |  | Transporte de material excedente a DMO, d>1km |  | 12d | 2024-12-06 | 2024-12-19 | 400195.1.05.09 SS | 335d | 0d |  | SI |  |  |
| 400195.1.05.01 |  | Excavación en material común para accesos |  | 8d | 2024-12-19 | 2024-12-27 | 400195.1.05.08 | 17d | 0d | 29760 | SI | m3 |  |
| 400195.1.05.06 |  | Transporte de material excedente a DME, d<=1km |  | 3d | 2024-12-20 | 2024-12-23 | 400195.1.05.01 SS+1d | 386d | 0d |  | SI |  |  |
| 400195.1.05.07 |  | Transporte de material excedente a DME, d>1km |  | 7d | 2024-12-20 | 2024-12-27 | 400195.1.05.06 SS | 386d | 184d |  | SI |  |  |
| 400195.1.05.03 |  | Proceso y selección de material propio |  | 9d | 2024-12-21 | 2024-12-31 | 400195.1.05.01 SS+2d | 328d | 0d | 3720 | SI | m3 |  |
| 400195.1.05.04 |  | Transporte de material propio para relleno, d<=1km |  | 15d | 2024-12-23 | 2025-01-08 | 400195.1.05.03 SS+1d | 328d | 0d | 9300 | SI | m3 |  |
| 400195.1.05.05 |  | Transporte de material propio para relleno, d>1km |  | 2d | 2024-12-23 | 2024-12-24 | 400195.1.05.04 SS | 341d | 194d |  |  |  |  |
| 400195.1.05.02 |  | Relleno compactado con equipo pesado para accesos |  | 13d | 2024-12-28 | 2025-01-11 | 400195.1.05.01 | 17d |  | 3720 | SI | m3 |  |
| 400195.1.05.11 |  | Habilitación de acceso temporal en cauce de río (Inc. Instalación y Retiro de alcantarilla) |  | 9d | 2024-12-28 | 2025-01-07 | 400195.1.05.01 | 430d |  |  | SI |  |  |
|  | 3 | **REHABILITACIÓN DE ACCESOS EXISTENTES** |  |  | 2024-12-19 | 2025-01-31 |  |  |  |  |  |  |  |
| 400195.1.06.01 |  | Rehabilitación de accesos existentes |  | 16d | 2024-12-19 | 2025-01-06 | 400195.1.05.08 | 0d |  | 1275 | SI | m3 |  |
| 400195.1.06.02 |  | Suministro, transporte e instalación de alcantarillas HDPE corrugada DN 300 mm, para cruce sobre canal |  | 2d | 2025-01-07 | 2025-01-08 | 400195.1.06.01 | 0d |  |  | SI |  |  |
| 400195.1.06.03 |  | Suministro, transporte e instalación de alcantarillas HDPE corrugada DN 450 mm, para cruce sobre canal |  | 6d | 2025-01-09 | 2025-01-15 | 400195.1.06.02 | 0d |  |  |  |  |  |
| 400195.1.06.04 |  | Suministro, transporte e instalación de alcantarillas HDPE corrugada DN 600 mm, para cruce sobre canal |  | 10d | 2025-01-09 | 2025-01-20 | 400195.1.06.03 SS | 0d |  |  |  |  |  |
| 400195.1.06.05 |  | Suministro, transporte e instalación de alcantarillas HDPE corrugada DN 750 mm, para cruce sobre canal |  | 4d | 2025-01-21 | 2025-01-24 | 400195.1.06.04 | 0d |  |  |  |  |  |
| 400195.1.06.06 |  | Suministro, transporte e instalación de alcantarillas HDPE corrugada DN 900 mm, para cruce sobre canal |  | 7d | 2025-01-21 | 2025-01-28 | 400195.1.06.05 SS | 0d |  |  |  |  |  |
| 400195.1.06.07 |  | Suministro, transporte e instalación de alcantarillas HDPE corrugada DN 1200 mm, para cruce sobre canal |  | 10d | 2025-01-21 | 2025-01-31 | 400195.1.06.06 SS | 0d |  |  |  |  |  |

| ID | WBS | Activity | Duration | Start | Finish | Predecessors | Total float | Free float | Metrado | Paquetes | Unidad | Filtro |
| --- | --- | --- | --- | --- | --- | --- | --- | --- | --- | --- | --- | --- |
|  | 4 | **MANTENIMIENTO DE ACCESOS (L<15 km)** |  | 2024-12-02 | 2026-04-15 |  |  |  |  |  |  |  |
| 400195.1.07 |  | Mantenimiento de accesos (L<15 km) | 429d | 2024-12-02 | 2026-04-15 | 400195.1.10 SS | 33d | 0d | 10 | SI | mes |  |
|  | 5 | **CONFORMACIÓN DE ATAGUÍA PARA DESVÍO TEMPORAL DE CAUCE DE RÍO** |  | 2024-12-05 | 2025-09-13 |  |  |  |  |  |  |  |
| 400195.1.08.01 |  | Conformación de ataguía para desvío temporal de cauce de río | 207d | 2024-12-05 | 2025-08-02 | 400195.1.05.08 SS, 400195.1.06.07 FF | 216d | 0d |  | SI |  |  |
| 400195.1.08.02 |  | Conformación de ataguía con revestimiento con bolsa de geotextil tejido de alta resistencia para desvío temporal de cauc | 243d | 2024-12-05 | 2025-09-13 | 400195.1.08.01 SS | 216d |  |  | SI |  |  |
|  | 6 | **SEÑALIZACIÓN DE OBRA** |  | 2024-12-02 | 2024-12-02 |  |  |  |  |  |  |  |
| 400195.1.09 |  | Señalización de obra | 1d | 2024-12-02 | 2024-12-02 | 400195.1.07 SS | 76d | 0d | 10 | SI | mes |  |
|  | 7 | **MOVILIZACIÓN DE EQUIPOS A OBRA** |  | 2024-12-02 | 2025-02-08 |  |  |  |  |  |  |  |
| 400195.1.10 |  | Movilización de equipos a obra | 60d | 2024-12-02 | 2025-02-08 | A5620 | 0d |  | 1 | SI | glb |  |
|  | 8 | **DESMOVILIZACIÓN DE EQUIPOS A OBRA** |  | 2026-04-20 | 2026-05-23 |  |  |  |  |  |  |  |
| 400195.1.11 |  | Desmovilización de equipos de obra | 30d | 2026-04-20 | 2026-05-23 | 400195.2.02.03, 400195.3.02.03, 400195.4.03.03 FF, 400195.5.02.03, 400195.6.03.03 FF+2d, 400195.9.01.09 FF, 400195.2.02.04, 400195.3.02.04, 400195.4.03.04, 400195.5.02.04 FF, 400195.6.03.04 FF, 400195.8.02.13 FF, 400195.9.01.10 FF, 400195.4.05.05, 400195.9.01.05, 400195.9.01.14, 400195.9.01.17, 400195.9.03.07 FF, 400195.1.15 FF, 400195.9.01.03 FF, 400195.8.02.14 FF, 400195.8.02.16 FF, 400195.9.01.12 FF, 400195.9.03.05 FF, 400195.9.02.03 FF, 400195.9.01.15 FF, 400195.6.02.03 FF, 400195.4.04.04 FF, 400195.6.02.15 FF, 400195.7.02.16 FF, 400195.10.03 FF, 400195.6.02.06 FF, 400195.6.02.07 FF, 400195.6.03.02 FF, 400195.4.06.01 FF, 400195.6.01.03 FF | 0d |  | 1 | SI | glb |  |
|  | 9 | **CONSTRUCCIÓN DE CAMPAMENTOS (TALLERES, ALMACENES Y OFICINAS)** |  | 2024-12-06 | 2026-05-09 |  |  |  |  |  |  |  |
| 400195.1.12.04 |  | Desbroce y remoción de suelo vegetal con equipo | 12d | 2024-12-06 | 2024-12-19 | 400195.1.01 SS+4d | 12d | 0d | 46500 | SI | m2 |  |
| 400195.1.12.05 |  | Transporte de material excedente a DMO, d<=1km | 25d | 2024-12-06 | 2025-01-03 | 400195.1.12.04 SS | 383d | 0d | 36716.56 | SI | m3 | Transporte |
| 400195.1.12.06 |  | Transporte de material excedente a DMO, d>1km | 22d | 2024-12-06 | 2024-12-31 | 400195.1.12.05 SS | 386d | 161d |  |  |  |  |
| 400195.1.12.01 |  | Conformación de terraplén para campamentos | 47d | 2024-12-20 | 2025-02-12 | 400195.1.12.04 | 12d | 0d | 150 | SI | m2 |  |
| 400195.1.12.02 |  | Construcción de campamentos | 1d | 2025-02-13 | 2025-02-13 | 400195.1.12.01 | 12d | 0d | 100 | SI | m2 |  |
| 400195.1.12.03 |  | Mantenimiento de campamentos | 386d | 2025-02-14 | 2026-05-09 | 400195.1.12.02 | 12d |  | 10 | SI | mes |  |
|  | 13 | **IMPLEMENTACIÓN DE CONTROLES AMBIENTALES DURANTE LA CONSTRUCCIÓN** |  | 2024-12-02 | 2026-02-24 |  |  |  |  |  |  |  |
| 400195.1.13 |  | Implementación de controles ambientales durante la construcción | 386d | 2024-12-02 | 2026-02-24 | 400195.1.09 SS | 76d |  | 11 | SI | mes |  |
|  | 14 | **ACONDICIONAMIENTO DE TERRENOS PARA DME Y DMO** |  | 2024-12-04 | 2025-04-08 |  |  |  |  |  |  |  |
| 400195.1.14.03 |  | Desbroce y remoción de suelo vegetal con equipo | 108d | 2024-12-04 | 2025-04-08 | 400195.1.01 SS+2d | 11d | 0d | 41366.56 | SI | m3 |  |
| 400195.1.14.04 |  | Transporte de material excedente a DMO, d<=1km | 85d | 2024-12-04 | 2025-03-12 | 400195.1.14.03 SS | 359d | 0d | 41366.56 | SI | m3 |  |
| 400195.1.14.05 |  | Transporte de material excedente a DMO, d>1km | 51d | 2024-12-04 | 2025-01-31 | 400195.1.14.04 SS | 359d | 184d | 41366.56 | SI | m3 |  |
| 400195.1.14.01 |  | Acondicionamiento de terrenos para DME y DMO | 74d | 2024-12-05 | 2025-02-28 | 400195.1.10 SS, 400195.1.14.03 SS+1d | 11d |  | 8273.31 | SI | m2 |  |
| 400195.1.14.02 |  | Conformación de material excedente en DME y DMO | 104d | 2024-12-06 | 2025-04-05 | 400195.1.05.09 SS, 400195.1.05.10 SS | 335d | 0d | 41366.56 | SI | m3 |  |

| ID | WBS | Activity | Duration | Start | Finish | Predecessors | Total float | Free float | Paquetes | enrocado |
| --- | --- | --- | --- | --- | --- | --- | --- | --- | --- | --- |
|  | 16 | **RESTAURACIÓN Y REVEGETACIÓN DE ÁREAS INTERVENIDAS** |  | 2025-04-07 | 2025-04-28 |  |  |  |  |  |
| 400195.1.15 |  | Restauración y revegetación de áreas intervenidas | 19d | 2025-04-07 | 2025-04-28 | 400195.1.14.02 | 335d |  | SI |  |
|  | 2 | **ENCAUZAMIENTO DE RÍO - SECTOR 1** |  | 2025-07-07 | 2026-01-26 |  |  |  |  |  |
|  | 2 | **MOVIMIENTO DE TIERRAS PARA DIQUE LONGITUDINALES - SECTOR 1** |  | 2025-07-07 | 2025-12-13 |  |  |  |  |  |
| 400195.2.01.01 |  | Desbroce y remoción de suelo vegetal con equipo | 41d | 2025-07-07 | 2025-08-22 | 400195.4.02.01, 400195.4.02.04 | 2.2d | 0d | NO |  |
| 400195.2.01.02 |  | Transporte de material excedente a DMO, d<=1km | 41d | 2025-07-08 | 2025-08-23 | 400195.2.01.01 SS+1d | 225d | 0d | NO |  |
| 400195.2.01.03 |  | Transporte de material excedente a DMO, d>1km | 40d | 2025-07-08 | 2025-08-22 | 400195.2.01.02 SS, 400195.1.12.06 | 225d | 50d | NO |  |
| 400195.2.01.04 |  | Excavación en material común | 30d | 2025-07-30 | 2025-09-02 | 400195.2.01.01 SS+20d | 2.2d | 0d | NO |  |
| 400195.2.01.07 |  | Transporte de material excedente a DME, d<=1km | 43d | 2025-07-31 | 2025-09-18 | 400195.2.01.04 SS+1d, 400195.1.05.07 | 202d | 0d | NO |  |
| 400195.2.01.08 |  | Transporte de material excedente a DME, d>1km | 43d | 2025-07-31 | 2025-09-18 | 400195.2.01.07 SS | 202d | 1d | NO |  |
| 400195.2.01.09 |  | Conformación y compactación de superficie para fundación con equipo pesado | 43d | 2025-08-01 | 2025-09-19 | 400195.2.01.04 SS+2d | 51.8d | 0d | NO |  |
| 400195.2.01.14 |  | Proceso y selección de material propio | 80d | 2025-08-01 | 2025-11-01 | 400195.2.01.04 SS+2d | 147d | 0d | SI |  |
| 400195.2.01.15 |  | Transporte de material propio para relleno, d<=1km | 88d | 2025-08-08 | 2025-11-18 | 400195.2.01.14 SS+6d, 400195.1.05.04 | 147d | 0d | SI |  |
| 400195.2.01.16 |  | Transporte de material propio para relleno, d>1km | 88d | 2025-08-08 | 2025-11-18 | 400195.2.01.15 SS, 400195.1.05.05 | 147d | 40d |  |  |
| 400195.2.01.10 |  | Relleno compactado con equipo pesado | 80d | 2025-08-15 | 2025-11-15 | 400195.2.01.09 SS+12d | 51.8d | 0d | SI |  |
| 400195.2.01.12 |  | Perfilado de taludes de dique con equipo | 73d | 2025-08-22 | 2025-11-14 | 400195.2.01.10 SS+6d | 51.8d | 0d | SI |  |
| 400195.2.01.05 |  | Excavación para conformación de uña antisocavante | 58d | 2025-08-29 | 2025-11-04 | 400195.2.01.12 SS+6d | 51.8d | 0d | NO |  |
| 400195.2.01.13 |  | Suministro, habilitación y colocación de geotextil no tejido 400 g/m2 | 65d | 2025-09-05 | 2025-11-19 | 400195.2.01.05 SS+6d, 400195.2.01.06 FF | 51.8d | 0d | SI |  |
| 400195.2.01.17 |  | Colocación de protección para geotextil | 70d | 2025-09-08 | 2025-11-27 | 400195.2.01.13 SS+2d, 400195.4.02.06 | 77.2d | 75d |  |  |
| 400195.2.01.06 |  | Excavación de zanja de anclaje para geotextil | 7d | 2025-10-01 | 2025-10-08 | 400195.2.01.10 SS+40d | 87.8d | 36d | SI |  |
| 400195.2.01.11 |  | Relleno propio sin compactar | 35d | 2025-11-04 | 2025-12-13 | 400195.2.02.04 SS+4d | 24d | 0d | SI |  |
|  | 3 | **ENROCADO DE PROTECCIÓN - SECTOR 1** |  | 2025-10-30 | 2026-01-26 |  |  |  |  |  |
| 400195.2.02.01 |  | Transporte de roca seleccionada de cantera para enrocado de protección, d<=1km | 69d | 2025-10-30 | 2026-01-17 | 400195.2.02.04 SS | 8d | 0d | SI | enro |
| 400195.2.02.02 |  | Transporte de roca seleccionada de cantera para enrocado de protección, d>1km | 72d | 2025-10-30 | 2026-01-21 | 400195.2.02.01 SS | 8d | 0d | SI | enro |
| 400195.2.02.04 |  | Colocación de roca seleccionada, en uña antisocavante | 67d | 2025-10-30 | 2026-01-15 | 400195.2.01.13 SS+3.2d, 400195.4.03.03 | 8d | 0d | NO | enro |
| 400195.2.02.03 |  | Colocación de roca seleccionada, en cara húmeda de talud | 70d | 2025-11-06 | 2026-01-26 | 400195.2.02.04 SS+6d | 71d | 0d | NO | enro |

| ID | WBS | Activity | Duration | Start | Finish | Predecessors | Total float | Free float | Paquetes |
| --- | --- | --- | --- | --- | --- | --- | --- | --- | --- |
|  | 4 | **REMOCION DE ENROCADO DE DIQUES EN MAL ESTADO - SECTOR 1** |  | 2025-11-25 | 2026-01-14 |  |  |  |  |
| 400195.2.03.01 |  | Remoción de enrocado de cara húmeda de talud | 17d | 2025-11-25 | 2025-12-13 | 400195.2.02.03 SS+16d | 107d | 0d | NO |
| 400195.2.03.02 |  | Selección y acopio de roca removida | 25d | 2025-12-15 | 2026-01-12 | 400195.2.03.01 | 107d | 0d | NO |
| 400195.2.03.03 |  | Transporte de roca rechazada a DME, d<=1km | 25d | 2025-12-17 | 2026-01-14 | 400195.2.03.02 SS+2d | 107d | 0d | NO |
| 400195.2.03.04 |  | Transporte de roca rechazada a DME, d>1km | 25d | 2025-12-17 | 2026-01-14 | 400195.2.03.03 SS | 107d | 31d | NO |
|  | 5 | **SISTEMA DE CONFINAMIENTO CON GEOCELDAS - SECTOR 1** |  | 2025-09-03 | 2025-10-28 |  |  |  |  |
| 400195.2.04.01 |  | Suministro, habilitación y colocación de geotextil no tejido 200 g/m2 | 39d | 2025-09-03 | 2025-10-17 | 400195.2.01.10 SS+16d | 95d | 0d | NO |
| 400195.2.04.02 |  | Suministro, habilitación y colocación de sistema de confinamiento geocelda h=100 mm | 47d | 2025-09-04 | 2025-10-28 | 400195.2.04.01 SS+1d | 95d | 0d | NO |
| 400195.2.04.03 |  | Suministro y colocación de concreto premezclado f'c=210 kg/cm2 para geocelda | 45d | 2025-09-06 | 2025-10-28 | 400195.2.04.02 SS+2d | 95d | 0d | NO |
| 400195.2.04.04 |  | Transporte de concreto premezclado con camión mixer, d<=1km | 45d | 2025-09-06 | 2025-10-28 | 400195.2.04.03 SS | 166d | 0d | NO |
| 400195.2.04.05 |  | Transporte de concreto premezclado con camión mixer, d>1km | 45d | 2025-09-06 | 2025-10-28 | 400195.2.04.04 SS | 166d | 55d | NO |
|  | 3 | **ENCAUZAMIENTO DE RÍO - SECTOR 2** |  | 2025-09-03 | 2026-01-07 |  |  |  |  |
|  | 2 | **MOVIMIENTO DE TIERRAS PARA DIQUE LONGITUDINALES - SECTOR 2** |  | 2025-09-03 | 2025-12-05 |  |  |  |  |
| 400195.3.01.01 |  | Desbroce y remoción de suelo vegetal con equipo | 14d | 2025-09-03 | 2025-09-18 | 400195.2.01.01, 400195.2.01.04 | 2.2d | 0d | NO |
| 400195.3.01.02 |  | Transporte de material excedente a DMO, d<=1km | 14d | 2025-09-04 | 2025-09-19 | 400195.3.01.01 SS+1d, 400195.1.14.05, 400195.1.12.05 | 175d | 0d | NO |
| 400195.3.01.03 |  | Transporte de material excedente a DMO, d>1km | 14d | 2025-09-04 | 2025-09-19 | 400195.3.01.02 SS, 400195.2.01.03 SS | 175d | 26d | NO |
| 400195.3.01.04 |  | Excavación en material común | 10d | 2025-09-19 | 2025-09-30 | 400195.3.01.01, 400195.2.01.04 | 2.2d | 0d | NO |
| 400195.3.01.07 |  | Transporte de material excedente a DME, d<=1km | 4d | 2025-09-20 | 2025-09-24 | 400195.3.01.04 SS+1d, 400195.2.01.08 | 201d | 41d | NO |
| 400195.3.01.08 |  | Conformación y compactación de superficie para fundación con equipo pesado | 12d | 2025-09-22 | 2025-10-04 | 400195.3.01.04 SS+2d | 2.2d | 0d | NO |
| 400195.3.01.13 |  | Proceso y selección de material propio | 23d | 2025-09-22 | 2025-10-17 | 400195.3.01.04 SS+2d | 107d | 0d | SI |
| 400195.3.01.14 |  | Transporte de material propio para relleno, d<=1km | 21d | 2025-09-24 | 2025-10-17 | 400195.3.01.13 SS+2d, 400195.2.01.16 SS | 107d | 29d | SI |
| 400195.3.01.09 |  | Relleno compactado con equipo pesado | 23d | 2025-09-26 | 2025-10-22 | 400195.3.01.08 SS+4d | 2.2d | 0d | SI |
| 400195.3.01.11 |  | Perfilado de taludes de dique con equipo | 20d | 2025-10-01 | 2025-10-23 | 400195.3.01.09 SS+4d | 2.2d | 0d | SI |
| 400195.3.01.05 |  | Excavación para conformación de uña antisocavante | 13d | 2025-10-06 | 2025-10-20 | 400195.3.01.11 SS+4d | 2.2d | 0d | NO |
| 400195.3.01.12 |  | Suministro, habilitación y colocación de geotextil no tejido 400 g/m2 | 45d | 2025-10-15 | 2025-12-05 | 400195.3.01.05 SS+8d | 8.6d | 0d | SI |
| 400195.3.01.06 |  | Colocación de protección para geotextil | 16d | 2025-10-17 | 2025-11-04 | 400195.3.01.12 SS+2d, 400195.4.02.17 SS | 8.6d |  | SI |
| 400195.3.01.10 |  | Relleno propio sin compactar | 16d | 2025-11-01 | 2025-11-19 | 400195.3.02.04 SS+2d | 105d | 102d | SI |

| ID | WBS | Activity | Duration | Start | Finish | Predecessors | Total float | Free float | Paquetes | enrocado | Metrado | Unidad |
| --- | --- | --- | --- | --- | --- | --- | --- | --- | --- | --- | --- | --- |
|  | 3 | **ENROCADO DE PROTECCIÓN - SECTOR 2** |  | 2025-10-30 | 2026-01-07 |  |  |  |  |  |  |  |
| 400195.3.02.01 |  | Transporte de roca seleccionada de cantera para enrocado de protección, d<=1km | 56d | 2025-10-30 | 2026-01-02 | 400195.3.02.04 SS | 8d | 0d | SI | enro |  |  |
| 400195.3.02.02 |  | Transporte de roca seleccionada de cantera para enrocado de protección, d>1km | 55d | 2025-10-30 | 2026-01-01 | 400195.3.02.01 SS, 400195.2.02.02 SS | 8d |  | SI | enro |  |  |
| 400195.3.02.04 |  | Colocación de roca seleccionada, en uña antisocavante | 50d | 2025-10-30 | 2025-12-26 | 400195.4.03.03, 400195.3.01.06 SS+2.4d | 0d |  | NO | enro |  |  |
| 400195.3.02.03 |  | Colocación de roca seleccionada, en cara húmeda de talud | 56d | 2025-11-04 | 2026-01-07 | 400195.3.02.04 SS+4d | 0d |  | SI | enro |  |  |
|  | 4 | **ENCAUZAMIENTO DE RÍO - SECTOR 3** |  | 2025-02-01 | 2026-01-29 |  |  |  |  |  |  |  |
|  | 1 | **DESCOLMATACIÓN DE CAUCE DE RÍO - SECTOR 3** |  | 2025-02-01 | 2025-02-26 |  |  |  |  |  |  |  |
| 400195.4.01.01 |  | Excavación en material común saturado | 20d | 2025-02-01 | 2025-02-24 | 400195.1.02 SS+9.6d, 400195.1.05.02, 400195.1.06.07 | 0d |  | NO |  |  |  |
| 400195.4.01.02 |  | Transporte de material común saturado excedente a DME, d<=1km | 21d | 2025-02-03 | 2025-02-26 | 400195.4.01.01 SS+1d | 373d | 0d | SI |  |  |  |
| 400195.4.01.03 |  | Transporte de material común saturado excedente a DME, d>1km | 21d | 2025-02-03 | 2025-02-26 | 400195.4.01.02 SS | 373d | 277d | NO |  |  |  |
|  | 2 | **MOVIMIENTO DE TIERRAS PARA DIQUE LONGITUDINALES - SECTOR 3** |  | 2025-02-19 | 2025-10-17 |  |  |  |  |  |  |  |
| 400195.4.02.01 |  | Desbroce y remoción de suelo vegetal con equipo | 90d | 2025-02-19 | 2025-06-03 | 400195.4.01.01 SS+15d | 0d |  | NO |  |  |  |
| 400195.4.02.02 |  | Transporte de material excedente a DMO, d<=1km | 104d | 2025-02-19 | 2025-06-19 | 400195.4.02.01 SS | 273d | 0d | NO |  |  |  |
| 400195.4.02.03 |  | Transporte de material excedente a DMO, d>1km | 104d | 2025-02-19 | 2025-06-19 | 400195.4.02.01 SS, 400195.4.02.02 SS | 273d | 194d | NO |  |  |  |
| 400195.4.02.04 |  | Excavación en material común | 98d | 2025-03-14 | 2025-07-05 | 400195.1.14.01, 400195.4.02.01 SS+20d | 0d |  | NO |  |  |  |
| 400195.4.02.07 |  | Transporte de material excedente a DME, d<=1km | 112d | 2025-03-14 | 2025-07-22 | 400195.4.02.04 SS | 98d | 0d | NO |  |  |  |
| 400195.4.02.08 |  | Transporte de material excedente a DME, d>1km | 101d | 2025-03-14 | 2025-07-09 | 400195.4.02.07 SS | 98d | 0d | NO |  |  |  |
| 400195.4.02.09 |  | Conformación y compactación de superficie para fundación con equipo pesado | 122d | 2025-03-24 | 2025-08-12 | 400195.4.02.04 SS+8d | 0d |  | NO |  |  |  |
| 400195.4.02.10 |  | Relleno compactado con equipo pesado | 133d | 2025-03-31 | 2025-09-01 | 400195.4.02.09 SS+6d | 0d |  | SI |  |  |  |
| 400195.4.02.14 |  | Proceso y selección de material propio | 133d | 2025-03-31 | 2025-09-01 | 400195.4.02.04 SS+2.4d, 400195.4.02.10 SS | 224d | 0d | SI |  |  |  |
| 400195.4.02.15 |  | Transporte de material propio para relleno, d<=1km | 133d | 2025-04-02 | 2025-09-03 | 400195.4.02.14 SS+2d | 224d | 0d | SI |  |  |  |
| 400195.4.02.16 |  | Transporte de material propio para relleno, d>1km | 133d | 2025-04-02 | 2025-09-03 | 400195.4.02.15 SS | 224d | 101d | SI |  | 41366.56 | m3 |
| 400195.4.02.12 |  | Perfilado de taludes de dique con equipo | 136d | 2025-04-04 | 2025-09-09 | 400195.4.02.10 SS+4d | 0d |  | SI |  |  |  |
| 400195.4.02.06 |  | Excavación de zanja de anclaje para geotextil | 30d | 2025-04-05 | 2025-05-09 | 400195.4.02.12 SS+1d | 180.2d | 103d | SI |  |  |  |
| 400195.4.02.05 |  | Excavación para conformación de uña antisocavante | 143d | 2025-04-09 | 2025-09-22 | 400195.4.02.12 SS+4d | 0d |  | NO |  |  |  |
| 400195.4.02.13 |  | Suministro, habilitación y colocación de geotextil no tejido 400 g/m2 | 147d | 2025-04-12 | 2025-09-30 | 400195.4.02.05 SS+3d | 0d |  | SI |  |  |  |
| 400195.4.02.17 |  | Colocación de protección para geotextil | 159d | 2025-04-16 | 2025-10-17 | 400195.4.02.13 SS+3d | 0d |  |  |  |  |  |
| 400195.4.02.11 |  | Relleno propio sin compactar | 138d | 2025-04-25 | 2025-10-02 | 400195.4.03.04 SS+6d | 88d | 8d | SI |  |  |  |

| ID | WBS | Activity | Duration | Start | Finish | Predecessors | Total float | Free float | Paquetes | enrocado |
| --- | --- | --- | --- | --- | --- | --- | --- | --- | --- | --- |
|  | 3 | **ENROCADO DE PROTECCIÓN - SECTOR 3** |  | 2025-04-18 | 2025-10-29 |  |  |  |  |  |
| 400195.4.03.01 |  | Transporte de roca seleccionada de cantera para enrocado de protección, d<=1km | 160d | 2025-04-18 | 2025-10-21 | 400195.4.03.04 SS | 184d | 0d | SI | enro |
| 400195.4.03.02 |  | Transporte de roca seleccionada de cantera para enrocado de protección, d>1km | 160d | 2025-04-18 | 2025-10-21 | 400195.4.03.01 SS | 184d | 227d | SI | enro |
| 400195.4.03.04 |  | Colocación de roca seleccionada, en uña antisocavante | 163d | 2025-04-18 | 2025-10-24 | 400195.4.02.17 SS+2d | 0d |  | NO | enro |
| 400195.4.03.03 |  | Colocación de roca seleccionada, en cara húmeda de talud | 160d | 2025-04-26 | 2025-10-29 | 400195.4.03.04 SS+7d | 0d |  | NO | enro |
|  | 4 | **REMOCION DE ENROCADO DE DIQUES EN MAL ESTADO - SECTOR 3** |  | 2025-05-05 | 2025-06-17 |  |  |  |  |  |
| 400195.4.04.01 |  | Remoción de enrocado de cara húmeda de talud | 21d | 2025-05-05 | 2025-05-28 | 400195.4.03.03 SS+7d, 400195.4.02.11 SS | 80d | 0d | SI |  |
| 400195.4.04.02 |  | Selección y acopio de roca removida | 16d | 2025-05-29 | 2025-06-16 | 400195.4.04.01 | 292d | 0d | SI |  |
| 400195.4.04.03 |  | Transporte de roca rechazada a DME, d<=1km | 16d | 2025-05-30 | 2025-06-17 | 400195.4.04.02 SS+1d | 292d | 0d | SI |  |
| 400195.4.04.04 |  | Transporte de roca rechazada a DME, d>1km | 16d | 2025-05-30 | 2025-06-17 | 400195.4.04.03 SS | 292d |  | SI |  |
|  | 5 | **SISTEMA DE CONFINAMIENTO DE GEOCELDAS - SECTOR 3** |  | 2025-09-02 | 2026-01-22 |  |  |  |  |  |
| 400195.4.05.01 |  | Suministro, habilitación y colocación de geotextil no tejido 200 g/m2 | 100d | 2025-09-02 | 2025-12-26 | 400195.4.02.10 | 74d | 0d | NO |  |
| 400195.4.05.02 |  | Suministro, habilitación y colocación de sistema de confinamiento geocelda h=100 mm | 118d | 2025-09-03 | 2026-01-17 | 400195.4.05.01 SS+1d | 74d | 0d | SI |  |
| 400195.4.05.03 |  | Suministro y colocación de concreto premezclado f'c=210 kg/cm2 para geocelda | 118d | 2025-09-08 | 2026-01-22 | 400195.4.05.02 SS+4d | 74d | 0d | NO |  |
| 400195.4.05.04 |  | Transporte de concreto premezclado con camión mixer, d<=1km | 118d | 2025-09-08 | 2026-01-22 | 400195.4.05.03 SS | 74d | 0d | NO |  |
| 400195.4.05.05 |  | Transporte de concreto premezclado con camión mixer, d>1km | 118d | 2025-09-08 | 2026-01-22 | 400195.4.05.04 SS | 74d |  | NO |  |
|  | 6 | **ÁREAS DEGRADADAS** |  | 2025-03-21 | 2026-01-29 |  |  |  |  |  |
| 400195.4.06.01 |  | Carguío y transporte de residuos municipales, no municipales y residuos de la construcción y demolición | 270d | 2025-03-21 | 2026-01-29 | 400195.4.02.07 SS+6d, 400195.4.02.08 SS+6d | 98d |  |  |  |
|  | 5 | **ENCAUZAMIENTO DE RÍO - SECTOR 4** |  | 2025-10-21 | 2026-03-16 |  |  |  |  |  |
|  | 2 | **MOVIMIENTO DE TIERRAS PARA DIQUE LONGITUDINALES - SECTOR 4** |  | 2025-10-21 | 2026-02-17 |  |  |  |  |  |
| 400195.5.01.01 |  | Desbroce y remoción de suelo vegetal con equipo | 19d | 2025-10-21 | 2025-11-11 | 400195.3.01.05 | 2.2d | 0d | NO |  |
| 400195.5.01.02 |  | Transporte de material excedente a DMO, d<=1km | 19d | 2025-10-21 | 2025-11-11 | 400195.5.01.01 SS | 149d | 0d | NO |  |
| 400195.5.01.03 |  | Transporte de material excedente a DMO, d>1km | 19d | 2025-10-21 | 2025-11-11 | 400195.5.01.02 SS, 400195.3.01.03 | 149d | 70d | NO |  |
| 400195.5.01.04 |  | Excavación en material común | 8d | 2025-11-12 | 2025-11-20 | 400195.5.01.01 | 2.2d | 0d | NO |  |
| 400195.5.01.07 |  | Transporte de material excedente a DME, d<=1km | 2d | 2025-11-12 | 2025-11-13 | 400195.5.01.04 SS, 400195.3.01.07 | 160d | 84d | NO |  |
| 400195.5.01.13 |  | Proceso y selección de material propio | 54d | 2025-11-14 | 2026-01-15 | 400195.5.01.04 SS+2d, 400195.8.01.05 | 78d | 0d | SI |  |
| 400195.5.01.08 |  | Conformación y compactación de superficie para fundación con equipo pesado | 18d | 2025-11-17 | 2025-12-06 | 400195.5.01.04 SS+4d | 2.2d | 0d | SI |  |
| 400195.5.01.14 |  | Transporte de material propio para relleno, d<=1km | 34d | 2025-11-21 | 2025-12-30 | 400195.5.01.13 SS+6d, 400195.3.01.14 | 78d | 0d | SI |  |
| 400195.5.01.09 |  | Relleno compactado con equipo pesado | 54d | 2025-11-22 | 2026-01-23 | 400195.5.01.08 SS+5d, 400195.8.01.02 | 2.2d | 0d | NO |  |
| 400195.5.01.11 |  | Perfilado de taludes de dique con equipo | 58d | 2025-11-27 | 2026-02-02 | 400195.5.01.09 SS+4d | 2.2d | 0d | NO |  |
| 400195.5.01.05 |  | Excavación para conformación de uña antisocavante | 37d | 2025-12-04 | 2026-01-15 | 400195.5.01.11 SS+6d, 400195.2.01.17 SS | 2.2d | 0d | NO |  |
| 400195.5.01.12 |  | Suministro, habilitación y colocación de geotextil no tejido 400 g/m2 | 17d | 2025-12-18 | 2026-01-06 | 400195.5.01.05 SS+12d | 17.2d | 0d | SI |  |
| 400195.5.01.06 |  | Colocación de protección para geotextil | 6d | 2025-12-20 | 2025-12-26 | 400195.5.01.12 SS+2d, 400195.3.01.06 | 111d | 72d | NO |  |
| 400195.5.01.10 |  | Relleno propio sin compactar | 33d | 2026-01-10 | 2026-02-17 | 400195.5.02.04 SS+2d | 61d | 58d | NO |  |

| ID | WBS | Activity | Duration | Start | Finish | Predecessors | Total float | Free float | Paquetes | enrocado |
| --- | --- | --- | --- | --- | --- | --- | --- | --- | --- | --- |
|  | 3 | **ENROCADO DE PROTECCIÓN - SECTOR 4** |  | 2026-01-08 | 2026-03-16 |  |  |  |  |  |
| 400195.5.02.01 |  | Transporte de roca seleccionada de cantera para enrocado de protección, d<=1km | 49d | 2026-01-08 | 2026-03-05 | 400195.5.02.04 SS | 65d | 0d | SI | enro |
| 400195.5.02.02 |  | Transporte de roca seleccionada de cantera para enrocado de protección, d>1km | 51d | 2026-01-08 | 2026-03-07 | 400195.5.02.01 SS, 400195.4.03.02 SS | 65d | 58d | SI | enro |
| 400195.5.02.04 |  | Colocación de roca seleccionada, en uña antisocavante | 18d | 2026-01-08 | 2026-01-28 | 400195.3.02.03, 400195.3.01.12 SS+0.8d, 400195.5.01.12 SS+0.8d | 0d |  | NO | enro |
| 400195.5.02.03 |  | Colocación de roca seleccionada, en cara húmeda de talud | 55d | 2026-01-12 | 2026-03-16 | 400195.5.02.04 SS+3d, 400195.3.02.02 | 0d |  | SI | enro |
|  | 6 | **ENCAUZAMIENTO DE RÍO - SECTOR 5** |  | 2026-01-16 | 2026-05-21 |  |  |  |  |  |
|  | 1 | **DESCOLMATACIÓN DE CAUCE DE RÍO - SECTOR 5** |  | 2026-01-16 | 2026-01-31 |  |  |  |  |  |
| 400195.6.01.01 |  | Excavación en material común saturado | 14d | 2026-01-16 | 2026-01-31 | 400195.5.01.01, 400195.5.01.04, 400195.5.01.05 | 2.2d | 0d | NO |  |
| 400195.6.01.02 |  | Transporte de material común saturado excedente a DME, d<=1km | 14d | 2026-01-16 | 2026-01-31 | 400195.6.01.01 SS | 96d | 0d | NO |  |
| 400195.6.01.03 |  | Transporte de material común saturado excedente a DME, d>1km | 14d | 2026-01-16 | 2026-01-31 | 400195.6.01.02 SS, 400195.4.01.03 | 96d |  | SI |  |
|  | 2 | **MOVIMIENTO DE TIERRAS PARA DIQUE LONGITUDINALES - SECTOR 5** |  | 2026-02-02 | 2026-04-22 |  |  |  |  |  |
| 400195.6.02.01 |  | Desbroce y remoción de suelo vegetal con equipo | 15d | 2026-02-02 | 2026-02-18 | 400195.6.01.01 | 2.2d | 0d | NO |  |
| 400195.6.02.02 |  | Transporte de material excedente a DMO, d<=1km | 17d | 2026-02-02 | 2026-02-20 | 400195.6.02.01 SS | 79d | 0d | NO |  |
| 400195.6.02.03 |  | Transporte de material excedente a DMO, d>1km | 17d | 2026-02-02 | 2026-02-20 | 400195.6.02.02 SS, 400195.4.02.03, 400195.5.01.03 | 79d |  | NO |  |
| 400195.6.02.04 |  | Excavación en material común | 7d | 2026-02-19 | 2026-02-26 | 400195.5.01.04, 400195.6.02.01, 400195.6.01.01 | 2.2d | 0d | NO |  |
| 400195.6.02.07 |  | Transporte de material excedente a DME, d<=1km | 4d | 2026-02-20 | 2026-02-24 | 400195.6.02.04 SS+1d, 400195.4.02.08, 400195.5.01.07, 400195.2.03.04 | 76d |  | NO |  |
| 400195.6.02.13 |  | Proceso y selección de material propio | 30d | 2026-02-21 | 2026-03-27 | 400195.6.02.04 SS+2d | 49d | 0d | SI |  |
| 400195.6.02.08 |  | Conformación y compactación de superficie para fundación con equipo pesado | 7d | 2026-02-24 | 2026-03-03 | 400195.6.02.04 SS+4d | 2.2d | 0d | NO |  |
| 400195.6.02.14 |  | Transporte de material propio para relleno, d<=1km | 22d | 2026-02-26 | 2026-03-23 | 400195.6.02.13 SS+4d | 53d | 0d | SI |  |
| 400195.6.02.15 |  | Transporte de material propio para relleno, d>1km | 22d | 2026-02-26 | 2026-03-23 | 400195.6.02.14 SS | 53d |  | NO |  |
| 400195.6.02.09 |  | Relleno compactado con equipo pesado | 30d | 2026-03-03 | 2026-04-06 | 400195.6.02.08 SS+6d | 2.2d | 0d | SI |  |
| 400195.6.02.11 |  | Perfilado de taludes de dique con equipo | 29d | 2026-03-06 | 2026-04-08 | 400195.6.02.09 SS+3d | 2.2d | 0d | SI |  |
| 400195.6.02.05 |  | Excavación para conformación de uña antisocavante | 18d | 2026-03-11 | 2026-03-31 | 400195.6.02.11 SS+4d | 2.2d | 0d | NO |  |
| 400195.6.02.12 |  | Suministro, habilitación y colocación de geotextil no tejido 400 g/m2 | 18d | 2026-03-13 | 2026-04-02 | 400195.6.02.05 SS+2d, 400195.5.01.12 SS | 2.2d | 0d | SI |  |
| 400195.6.02.06 |  | Colocación de protección para geotextil | 22d | 2026-03-14 | 2026-04-08 | 400195.6.02.12 SS+1d, 400195.5.01.06 SS | 39d |  | SI |  |
| 400195.6.02.10 |  | Relleno propio sin compactar | 30d | 2026-03-19 | 2026-04-22 | 400195.6.03.04 SS+2d, 400195.3.01.10, 400195.5.01.10 SS | 3d |  | SI |  |

| ID | WBS | Activity | Duration | Start | Finish | Predecessors | Total float | Free float | Paquetes | enrocado |
| --- | --- | --- | --- | --- | --- | --- | --- | --- | --- | --- |
|  | 3 | **ENROCADO DE PROTECCIÓN - SECTOR 5** |  | 2026-03-17 | 2026-05-21 |  |  |  |  |  |
| 400195.6.03.01 |  | Transporte de roca seleccionada de cantera para enrocado de protección, d<=1km | 49d | 2026-03-17 | 2026-05-12 | 400195.6.03.04 SS, 400195.5.02.02 SS | 7d | 0d | SI | enro |
| 400195.6.03.02 |  | Transporte de roca seleccionada de cantera para enrocado de protección, d>1km | 52d | 2026-03-17 | 2026-05-15 | 400195.6.03.01 SS | 7d |  | SI | enro |
| 400195.6.03.04 |  | Colocación de roca seleccionada, en uña antisocavante | 35d | 2026-03-17 | 2026-04-25 | 400195.6.02.12 SS+0.8d, 400195.5.02.03 | 0d |  | NO | enro |
| 400195.6.03.03 |  | Colocación de roca seleccionada, en cara húmeda de talud | 52d | 2026-03-23 | 2026-05-21 | 400195.6.03.04 SS+5d, 400195.6.02.10 SS, 400195.10.01 FF | 0d |  | NO | enro |
|  | 7 | **ESTRUCTURA DE CAPTACIÓN LATERAL** |  | 2025-10-23 | 2025-12-16 |  |  |  |  |  |
|  | 8 | **MOVIMIENTO DE TIERRAS** |  | 2025-10-23 | 2025-12-04 |  |  |  |  |  |
| 400195.7.01.05 |  | Trazo y replanteo de interferencia | 4d | 2025-10-23 | 2025-10-27 | 400195.3.01.09 | 66d | 0d | NO |  |
| 400195.7.01.01 |  | Excavación en material común | 2d | 2025-10-29 | 2025-10-30 | 400195.7.02.11 | 66d | 0d | NO |  |
| 400195.7.01.04 |  | Proceso y selección de material propio | 1d | 2025-10-30 | 2025-10-30 | 400195.7.01.01 SS+1d | 141d | 28d | NO |  |
| 400195.7.01.06 |  | Relleno compactado para estructuras | 1d | 2025-12-03 | 2025-12-03 | 400195.7.03.04, 400195.7.01.04 | 113d | 0d | NO |  |
| 400195.7.01.02 |  | Relleno compactado con equipo pesado | 1d | 2025-12-04 | 2025-12-04 | 400195.7.01.06 | 113d | 0d | NO |  |
| 400195.7.01.03 |  | Transporte de material excedente a DME, d<=1km | 1d | 2025-12-04 | 2025-12-04 | 400195.7.01.02 SS | 113d | 9d | NO |  |
| 400195.7.01.07 |  | Relleno propio sin compactar | 1d | 2025-12-04 | 2025-12-04 | 400195.7.01.06, 400195.7.03.02 | 146d |  | NO |  |
|  | 5 | **OBRAS DE CONCRETO** |  | 2025-10-28 | 2025-12-06 |  |  |  |  |  |
| 400195.7.02.10 |  | Desvío provisional - tubería HPDE D=1200mm | 5d | 2025-10-28 | 2025-11-01 | 400195.7.01.05 | 90d | 24d | NO |  |
| 400195.7.02.11 |  | Desvío provisional - canal de tierra para estructuras de interferencias | 1d | 2025-10-28 | 2025-10-28 | 400195.7.01.05 | 66d | 0d | NO |  |
| 400195.7.02.01 |  | Suministro y colocación de concreto premezclado f'c=100 kg/cm2, e=0.10 m para solado | 1d | 2025-10-31 | 2025-10-31 | 400195.7.01.01 | 66d | 0d | NO |  |
| 400195.7.02.05 |  | Suministro, habilitación y colocación de acero de refuerzo f'y=4200 kg/cm2 | 30d | 2025-11-01 | 2025-12-05 | 400195.7.02.01 | 66d | 0d | NO |  |
| 400195.7.02.04 |  | Suministro, habilitación, encofrado y desencofrado para estructuras | 21d | 2025-11-06 | 2025-11-29 | 400195.7.02.05 SS+4d | 66d | 0d | NO |  |
| 400195.7.02.06 |  | Suministro y colocación de concreto estructural premezclado f'c=280 kg/cm2 | 6d | 2025-11-08 | 2025-11-14 | 400195.7.02.04 SS+2d | 78d | 0d | NO |  |
| 400195.7.02.08 |  | Transporte de concreto premezclado con camión mixer, d<=1km | 2d | 2025-11-08 | 2025-11-10 | 400195.7.02.06 SS | 153d | 0d | SI |  |
| 400195.7.02.09 |  | Transporte de concreto premezclado con camión mixer, d>1km | 8d | 2025-11-08 | 2025-11-17 | 400195.7.02.08 SS | 153d | 35d | NO |  |
| 400195.7.02.07 |  | Suministro y colocación de concreto estructural premezclado f'c=280 kg/cm2 en 2da fase | 1d | 2025-11-15 | 2025-11-15 | 400195.7.02.06 | 78d | 12d | NO |  |
| 400195.7.02.02 |  | Suministro y colocación de concreto ciclópeo f'c=175kg/cm2 + 30%PM | 1d | 2025-12-01 | 2025-12-01 | 400195.7.02.04 | 145d | 0d | NO |  |
| 400195.7.02.12 |  | Colocación de roca seleccionada, en uña antisocavante | 1d | 2025-12-01 | 2025-12-01 | 400195.7.02.04, 400195.7.02.07, 400195.7.02.10 | 66d | 0d | SI |  |
| 400195.7.02.13 |  | Junta de dilatación para mampostería con sellante elastomérico de poliuretano 1/2" | 1d | 2025-12-01 | 2025-12-01 | 400195.7.02.04 | 144d | 0d | NO |  |
| 400195.7.02.17 |  | Transporte de roca seleccionada de cantera para enrocado de protección, d<=1km | 1d | 2025-12-01 | 2025-12-01 | 400195.7.02.12 SS | 66d | 0d | NO |  |
| 400195.7.02.18 |  | Transporte de roca seleccionada de cantera para enrocado de protección, d>1km | 6d | 2025-12-01 | 2025-12-06 | 400195.7.02.17 SS | 66d | 42d | NO |  |
| 400195.7.02.03 |  | Suministro y colocación de mampostería de piedra de concreto 70%pm + 30% concreto f'c=175 kg/cm2 | 3d | 2025-12-02 | 2025-12-04 | 400195.7.02.02 | 145d | 1d | SI |  |
| 400195.7.02.14 |  | Junta de contracción para mampostería con junta asfáltica 1"x1/2" | 2d | 2025-12-02 | 2025-12-03 | 400195.7.02.13 | 144d | 0d | NO |  |
| 400195.7.02.15 |  | Junta de dilatación para canales de concreto | 2d | 2025-12-04 | 2025-12-05 | 400195.7.02.14 | 144d | 0d | NO |  |
| 400195.7.02.16 |  | Junta de contracción para canales de concreto | 1d | 2025-12-06 | 2025-12-06 | 400195.7.02.15, 400195.7.02.03 | 144d |  | SI |  |

| ID | WBS | Activity | Duration | Start | Finish | Predecessors | Total float | Free float | Paquetes | Metrado | Unidad |
| --- | --- | --- | --- | --- | --- | --- | --- | --- | --- | --- | --- |
|  | 1 | **INSTALACIONES HIDRÁULICAS** |  | 2025-12-01 | 2025-12-16 |  |  |  |  |  |  |
| 400195.7.03.01 |  | Suministro, habilitación e instalación de compuerta tipo ARMCO Modelo 10, Izaje CPE-2, B=1400 x h=1400mm | 2d | 2025-12-01 | 2025-12-02 | 400195.7.02.04 | 146d | 0d | NO |  |  |
| 400195.7.03.03 |  | Impermeabilización de estructuras enterradas con pintura asfáltica | 14d | 2025-12-01 | 2025-12-16 | 400195.7.02.04 | 113d | 0d | SI |  |  |
| 400195.7.03.04 |  | Suministro, habilitación e instalación de baranda metálica de tubo Ø 2" F°G° h=0.90 m | 2d | 2025-12-01 | 2025-12-02 | 400195.7.02.04, 400195.7.03.03 SS | 113d | 0d | NO |  |  |
| 400195.7.03.02 |  | Suministro, habilitación e instalación de rejilla métalica de B=3.10 m x h=2.67 m | 1d | 2025-12-03 | 2025-12-03 | 400195.7.03.01 | 146d | 0d | NO |  |  |
|  | 12 | **ALCANTARILLA DE RETORNO** |  | 2025-10-23 | 2025-11-17 |  |  |  |  |  |  |
|  | 1 | **MOVIMIENTO DE TIERRAS** |  | 2025-10-23 | 2025-11-15 |  |  |  |  |  |  |
| 400195.8.01.06 |  | Trazo y replanteo de interferencia | 2d | 2025-10-23 | 2025-10-24 | 400195.3.01.09 | 7.2d | 0d | NO |  |  |
| 400195.8.01.01 |  | Excavación en material común | 1d | 2025-10-27 | 2025-10-27 | 400195.8.02.12 | 7.2d | 0d | NO |  |  |
| 400195.8.01.03 |  | Transporte de material excedente a DME, d<=1km | 1d | 2025-10-28 | 2025-10-28 | 400195.8.01.01 SS+1d | 145d | 0d | NO |  |  |
| 400195.8.01.04 |  | Transporte de material excedente a DME, d>1km | 1d | 2025-10-28 | 2025-10-28 | 400195.8.01.03 SS | 145d | 41d | NO |  |  |
| 400195.8.01.05 |  | Proceso y selección de material propio | 1d | 2025-10-28 | 2025-10-28 | 400195.8.01.01 SS+1d | 92d | 14d | NO |  |  |
| 400195.8.01.07 |  | Relleno compactado para estructuras | 5d | 2025-11-10 | 2025-11-14 | 400195.8.03.11 | 7.2d | 0d | NO |  |  |
| 400195.8.01.02 |  | Relleno compactado con equipo pesado | 1d | 2025-11-15 | 2025-11-15 | 400195.8.01.07 | 7.2d | 5d | NO |  |  |
| 400195.8.01.08 |  | Relleno propio sin compactar | 1d | 2025-11-15 | 2025-11-15 | 400195.8.01.07 | 155d | 64d | NO |  |  |
|  | 2 | **OBRAS DE CONCRETO** |  | 2025-10-25 | 2025-11-17 |  |  |  |  |  |  |
| 400195.8.02.11 |  | Desvío provisional - tubería HPDE D=1200mm | 3d | 2025-10-25 | 2025-10-28 | 400195.8.01.06 | 7.2d | 0d | NO |  |  |
| 400195.8.02.12 |  | Desvío provisional - canal de tierra para estructuras de interferencias | 1d | 2025-10-25 | 2025-10-25 | 400195.8.01.06, 400195.8.02.11 SS | 7.2d | 0d | NO |  |  |
| 400195.8.02.01 |  | Suministro y colocación de concreto premezclado f'c=100 kg/cm2, e=0.10 m para solado | 1d | 2025-10-28 | 2025-10-28 | 400195.8.01.01 | 7.2d | 0d | NO |  |  |
| 400195.8.02.02 |  | Suministro y colocación de cama de arena, e=0.20m para protección de tubería | 1d | 2025-10-28 | 2025-10-28 | 400195.8.01.01 | 173d | 9d | NO |  |  |
| 400195.8.02.06 |  | Suministro, habilitación y colocación de acero de refuerzo f'y=4200 kg/cm2 | 5d | 2025-10-29 | 2025-11-03 | 400195.8.02.01 | 7.2d | 0d | NO |  |  |
| 400195.8.02.05 |  | Suministro, habilitación, encofrado y desencofrado para estructuras | 5d | 2025-11-03 | 2025-11-07 | 400195.8.02.06 SS+4d | 7.2d | 0d | NO |  |  |
| 400195.8.02.07 |  | Suministro y colocación de concreto estructural premezclado f'c=280 kg/cm2 | 2d | 2025-11-05 | 2025-11-06 | 400195.8.02.05 SS+2d | 157d | 0d | NO |  |  |
| 400195.8.02.09 |  | Transporte de concreto premezclado con camión mixer, d<=1km | 2d | 2025-11-05 | 2025-11-06 | 400195.8.02.07 SS | 157d | 0d | NO |  |  |
| 400195.8.02.10 |  | Transporte de concreto premezclado con camión mixer, d>1km | 7d | 2025-11-05 | 2025-11-12 | 400195.8.02.09 SS | 157d | 39d | NO |  |  |
| 400195.8.02.08 |  | Suministro y colocación de concreto estructural premezclado f'c=280 kg/cm2 en 2da fase | 1d | 2025-11-07 | 2025-11-07 | 400195.8.02.07 | 167d | 3d | NO |  |  |
| 400195.8.02.03 |  | Suministro y colocación de concreto ciclópeo f'c=175kg/cm2 + 30%PM | 1d | 2025-11-08 | 2025-11-08 | 400195.8.02.05, 400195.8.02.02 | 164d | 0d | NO |  |  |
| 400195.8.02.13 |  | Colocación de roca seleccionada, en uña antisocavante | 1d | 2025-11-08 | 2025-11-08 | 400195.8.02.05 | 90d | 0d | NO |  |  |
| 400195.8.02.15 |  | Junta de dilatación para mampostería con sellante elastomérico de poliuretano 1/2" | 1d | 2025-11-08 | 2025-11-08 | 400195.8.02.05 | 167d | 0d | NO |  |  |
| 400195.8.02.17 |  | Transporte de roca seleccionada de cantera para enrocado de protección, d<=1km | 1d | 2025-11-08 | 2025-11-08 | 400195.8.02.13 SS | 90d | 0d | SI | 41366.56 | m3 |
| 400195.8.02.04 |  | Suministro y colocación de mampostería de piedra de concreto 70%pm + 30% concreto f'c=175 kg/cm2 | 2d | 2025-11-10 | 2025-11-11 | 400195.8.02.03 | 164d | 0d | NO |  |  |
| 400195.8.02.16 |  | Junta de contracción para mampostería con junta asfáltica 1"x1/2" | 1d | 2025-11-10 | 2025-11-10 | 400195.8.02.15 | 167d |  | NO |  |  |
| 400195.8.02.18 |  | Transporte de roca seleccionada de cantera para enrocado de protección, d>1km | 7d | 2025-11-10 | 2025-11-17 | 400195.8.02.17 SS+1d | 90d | 66d | SI | 41366.56 | m3 |
| 400195.8.02.14 |  | Suministro y colocación de enrocado con mortero (70% enrocado + 30% mortero f'c=175 kg/cm2) | 2d | 2025-11-12 | 2025-11-13 | 400195.8.02.04, 400195.8.02.08 | 164d |  | SI | 41366.56 | m3 |

| ID | WBS | Activity | Duration | Start | Finish | Predecessors | Total float | Free float | Paquetes |
| --- | --- | --- | --- | --- | --- | --- | --- | --- | --- |
|  | 3 | **INSTALACIONES HIDRÁULICAS** |  | 2025-11-05 | 2025-11-13 |  |  |  |  |
| 400195.8.03.10 |  | Suministro, habilitación e instalación de junta de estanquidad waterstop 6" | 1d | 2025-11-05 | 2025-11-05 | 400195.8.02.05 SS+2d | 9.2d | 2d | NO |
| 400195.8.03.01 |  | Suministro, habilitación e instalación de compuerta antirretorno tipo clapeta de DN 600 mm | 1d | 2025-11-08 | 2025-11-08 | 400195.8.02.05 | 164d | 0d | NO |
| 400195.8.03.11 |  | Impermeabilización de estructuras enterradas con pintura asfáltica | 1d | 2025-11-08 | 2025-11-08 | 400195.8.02.05, 400195.8.03.10 | 7.2d | 0d | NO |
| 400195.8.03.02 |  | Suministro, habilitación e instalación de compuerta antirretorno tipo clapeta de DN 750 mm | 1d | 2025-11-10 | 2025-11-10 | 400195.8.03.01 | 164d | 0d |  |
| 400195.8.03.04 |  | Suministro, habilitación e instalación de Tubería HDPE corrugado DN 600 mm | 1d | 2025-11-10 | 2025-11-10 | 400195.8.03.01 | 164d | 0d | NO |
| 400195.8.03.03 |  | Suministro, habilitación e instalación de compuerta antirretorno tipo clapeta de DN 1200 mm | 1d | 2025-11-11 | 2025-11-11 | 400195.8.02.05, 400195.8.03.01, 400195.8.03.02 | 164d | 0d | NO |
| 400195.8.03.05 |  | Suministro, habilitación e instalación de Tubería HDPE corrugado DN 750 mm | 1d | 2025-11-11 | 2025-11-11 | 400195.8.03.02 | 164d | 0d |  |
| 400195.8.03.07 |  | Suministro, habilitación e instalación de rejilla métalica de B=0.70 m x H=1.17 m | 1d | 2025-11-11 | 2025-11-11 | 400195.8.03.04 | 164d | 0d | NO |
| 400195.8.03.06 |  | Suministro, habilitación e instalación de Tubería HDPE corrugado DN 1200 mm | 1d | 2025-11-12 | 2025-11-12 | 400195.8.03.03 | 164d | 0d | NO |
| 400195.8.03.08 |  | Suministro, habilitación e instalación de rejilla métalica de B=1.35 m x H=1.24 m | 1d | 2025-11-12 | 2025-11-12 | 400195.8.03.05, 400195.8.03.07 | 164d | 0d |  |
| 400195.8.03.09 |  | Suministro, habilitación e instalación de rejilla métalica de B=1.80 m x H=1.98 m | 1d | 2025-11-13 | 2025-11-13 | 400195.8.03.06, 400195.8.03.08 | 164d |  | NO |
|  | 13 | **RAMPAS Y ACCESOS A CORONA** |  | 2025-12-15 | 2026-04-04 |  |  |  |  |
|  | 1 | **MOVIMIENTO DE TIERRAS PARA RAMPAS Y ACCESOS A CORONA** |  | 2025-12-15 | 2026-04-04 |  |  |  |  |
| 400195.9.01.01 |  | Excavación en material común | 8d | 2025-12-15 | 2025-12-23 | 400195.4.02.10, 400195.3.01.09, 400195.2.01.11 | 24d | 0d | NO |
| 400195.9.01.04 |  | Transporte de material excedente a DME, d<=1km | 3d | 2025-12-16 | 2025-12-18 | 400195.9.01.01 SS+1d, 400195.8.01.04, 400195.7.01.03 | 104d | 0d | NO |
| 400195.9.01.05 |  | Transporte de material excedente a DME, d>1km | 3d | 2025-12-16 | 2025-12-18 | 400195.9.01.04 SS | 104d |  | NO |
| 400195.9.01.13 |  | Proceso y selección de material propio | 22d | 2025-12-17 | 2026-01-10 | 400195.9.01.01 SS+2d | 89d | 11d | NO |
| 400195.9.01.06 |  | Conformación y compactación de superficie para fundación con equipo pesado | 5d | 2025-12-24 | 2025-12-29 | 400195.9.01.01 | 24d | 0d | NO |
| 400195.9.01.07 |  | Relleno compactado con equipo pesado | 22d | 2025-12-27 | 2026-01-21 | 400195.9.01.06 SS+3d | 24d | 0d | NO |
| 400195.9.01.14 |  | Transporte de material propio para relleno, d<=1km | 16d | 2025-12-31 | 2026-01-17 | 400195.9.01.13 SS+1d, 400195.5.01.14 | 78d | 0d | NO |
| 400195.9.01.15 |  | Transporte de material propio para relleno, d>1km | 1d | 2025-12-31 | 2025-12-31 | 400195.9.01.14 SS, 400195.4.02.16 | 123d |  | NO |
| 400195.9.01.08 |  | Perfilado de taludes de dique con equipo | 16d | 2026-01-03 | 2026-01-21 | 400195.9.01.07 SS+6d | 34.6d | 0d | NO |
| 400195.9.01.02 |  | Excavación para conformación de uña antisocavante | 29d | 2026-01-08 | 2026-02-10 | 400195.9.01.08 SS+4d | 34.6d | 10.6d | NO |
| 400195.9.01.03 |  | Excavación de zanja de anclaje para geotextil | 1d | 2026-01-22 | 2026-01-22 | 400195.9.01.07 | 24d | 0d | NO |
| 400195.9.01.11 |  | Suministro, habilitación y colocación de geotextil no tejido 400 g/m2 | 22d | 2026-01-23 | 2026-02-17 | 400195.9.01.02 SS+2.4d, 400195.9.01.03 | 24d | 0d | NO |
| 400195.9.01.10 |  | Colocación de roca seleccionada, en uña antisocavante | 52d | 2026-01-26 | 2026-03-26 | 400195.9.01.11 SS+2d | 24d | 0d | NO |
| 400195.9.01.16 |  | Transporte de roca seleccionada de cantera para enrocado de protección, d<=1km | 41d | 2026-01-26 | 2026-03-13 | 400195.9.01.10 SS, 400195.8.02.18 SS | 24d | 0d | NO |
| 400195.9.01.17 |  | Transporte de roca seleccionada de cantera para enrocado de protección, d>1km | 48d | 2026-01-26 | 2026-03-21 | 400195.9.01.16 SS, 400195.7.02.18 | 24d |  | NO |
| 400195.9.01.12 |  | Relleno propio sin compactar | 7d | 2026-01-30 | 2026-02-06 | 400195.9.01.10 SS+4d, 400195.8.01.08 | 91d |  | NO |
| 400195.9.01.09 |  | Colocación de roca seleccionada, en cara húmeda de talud | 54d | 2026-01-31 | 2026-04-04 | 400195.9.01.10 SS+5.6d | 42.4d |  | NO |

| ID | WBS | Activity | Duration | Start | Finish | Predecessors | Total float | Free float | Paquetes |
| --- | --- | --- | --- | --- | --- | --- | --- | --- | --- |
|  | 2 | **SISTEMA DE CONFINAMIENTO CON GEOCELDAS** |  | 2026-01-03 | 2026-01-17 |  |  |  |  |
| 400195.9.02.01 |  | Suministro, habilitación y colocación de geotextil no tejido 200 g/m2 | 6d | 2026-01-03 | 2026-01-09 | 400195.9.01.07 SS+6d | 108.2d | 0d | NO |
| 400195.9.02.02 |  | Suministro, habilitación y colocación de sistema de confinamiento geocelda h=200 mm | 10d | 2026-01-03 | 2026-01-15 | 400195.9.02.01 SS+0.8d, 400195.9.03.03 SS | 108.2d | 0d | NO |
| 400195.9.02.03 |  | Suministro y colocación de concreto premezclado f'c=210 kg/cm2 para geocelda | 6d | 2026-01-10 | 2026-01-17 | 400195.9.02.02 SS+6d | 108.2d |  | NO |
|  | 3 | **OBRAS DE CONCRETO** |  | 2025-12-24 | 2026-01-06 |  |  |  |  |
| 400195.9.03.01 |  | Suministro, habilitación, encofrado y desencofrado para estructuras | 2d | 2025-12-24 | 2025-12-25 | 400195.9.01.01 | 111d | 0d | NO |
| 400195.9.03.04 |  | Junta transversal de dilatación e=20mm en pavimento | 1d | 2025-12-26 | 2025-12-26 | 400195.9.03.01 | 125d | 0d | NO |
| 400195.9.03.05 |  | Junta transversal de contracción e=6mm en pavimento | 2d | 2025-12-27 | 2025-12-29 | 400195.9.03.04 | 125d |  | NO |
| 400195.9.03.02 |  | Suministro y colocación de concreto estructural premezclado f'c=280 kg/cm2 | 3d | 2025-12-29 | 2025-12-31 | 400195.9.03.01 SS+4d | 111d | 0d | NO |
| 400195.9.03.06 |  | Transporte de concreto premezclado con camión mixer, d<=1km | 8d | 2025-12-29 | 2026-01-06 | 400195.9.03.02 SS, 400195.8.02.10 | 118d | 0d | NO |
| 400195.9.03.07 |  | Transporte de concreto premezclado con camión mixer, d>1km | 8d | 2025-12-29 | 2026-01-06 | 400195.9.03.06 SS, 400195.7.02.09 | 118d |  | NO |
| 400195.9.03.03 |  | Suministro y colocación de mampostería de piedra de concreto 70%pm + 30% concreto f'c=175 kg/cm2 | 5d | 2026-01-01 | 2026-01-06 | 400195.9.03.02, 400195.2.04.05 | 111d | 2.8d | NO |
|  | 14 | **PRUEBAS DE CONTROL DE CALIDAD** |  | 2025-03-31 | 2026-05-12 |  |  |  |  |
| 400195.10.01 |  | Pruebas de control de calidad para suelos | 350d | 2025-03-31 | 2026-05-12 | 400195.4.02.10 SS | 8d |  | NO |
| 400195.10.03 |  | Ensayos de validación de diques existentes | 250d | 2025-05-05 | 2026-02-19 | 400195.4.04.01 SS | 80d |  | NO |
| 400195.10.02 |  | Pruebas de control de calidad para concreto | 115d | 2025-09-06 | 2026-01-17 | 400195.8.02.07 FF, 400195.2.04.03 SS | 95d | 83d | NO |
|  | 10 | **CANTERAS DE ROCA PARA PAQUETE 9** |  | 2024-12-02 | 2026-05-04 |  |  |  |  |
| 12.01.01 |  | Canteras paquete 9 | 445d | 2024-12-02 | 2026-05-04 | A5620 SS, 400195.1.10 SS | 17d |  | NO |

## Activity codes

| Code | Value | Meaning |
| --- | --- | --- |
| enrocado | enro | enrocado |
